# Ratatat project

Schedule from MS Project, 2009-04-01 to 2010-03-31.
CSG

## Calendars

- Standard: Mon-Fri 08:00-12:00, 13:00-17:00; Sat-Sun off.

## Schedule

| ID | WBS | Task | Type | Duration | Start | Finish | Predecessors | Total slack | Free slack | Constraint |
| --- | --- | --- | --- | --- | --- | --- | --- | --- | --- | --- |
| 1 | 1 | **Pre-Project Planning and Setup** |  | 23d | 2009-04-01 | 2009-05-01 |  | 235d |  |  |
| 2 | 1.1 | Project plan preparation |  | 9d | 2009-04-01 | 2009-04-13 |  | 249d |  | start no earlier than 2009-04-01 |
| 3 | 1.2 | Project team planning |  | 9d | 2009-04-01 | 2009-04-13 |  | 239d | 4d | start no earlier than 2009-04-01 |
| 4 | 1.3 | Project team appointments |  | 10d | 2009-04-20 | 2009-05-01 | 3 | 235d |  | start no earlier than 2009-04-20 |
| 5 | 1.4 | Project management group meeting | milestone | 1d | 2009-05-01 | 2009-05-01 |  | 235d |  |  |
| 6 | 2 | **Workpackage 1: Learning Environment Design** |  | 120d | 2009-05-01 | 2009-10-15 |  | 116d |  |  |
| 7 | 2.1 | T1: Learning environment specification |  | 20d | 2009-05-01 | 2009-05-28 |  | 116d | 0d |  |
| 8 | 2.2 | T2: Assembly of learning environment components |  | 20d | 2009-05-29 | 2009-06-25 | 7 | 116d | 0d |  |
| 9 | 2.3 | T3: Learning environment testing |  | 20d | 2009-06-26 | 2009-07-23 | 8 | 116d | 0d |  |
| 10 | 2.4 | T4 Learning environment development and refinement |  | 60d | 2009-07-24 | 2009-10-15 | 9 | 116d |  |  |
| 11 | 2.5 | Steering Group Meeting | milestone | 1d | 2009-07-24 | 2009-07-24 | 9 | 175d |  |  |
| 12 | 3 | **Workpackage 2: Laser Scanning Doppler Vibrometer** |  | 100d | 2009-05-01 | 2009-09-17 |  | 3d |  |  |
| 13 | 3.1 | T5: IT planning and design |  | 20d | 2009-05-01 | 2009-05-28 |  | 3d | 0d |  |
| 14 | 3.2 | T6: Development of remote access time-domain experiments |  | 20d | 2009-05-29 | 2009-06-25 | 13 | 3d | 0d |  |
| 15 | 3.3 | T7: Development of remote access frequency-domain experiments |  | 20d | 2009-06-26 | 2009-07-23 | 14 | 136d | 0d |  |
| 16 | 3.4 | T8: Testing and evaluation |  | 40d | 2009-07-24 | 2009-09-17 | 15 | 136d |  |  |
| 17 | 4 | **Workpackage 3: Digital Photoelastic Stress Measurement** |  | 80d | 2009-06-26 | 2009-10-15 |  | 3d |  |  |
| 18 | 4.1 | T9: Shear stress/strain in birefringent materials |  | 20d | 2009-06-26 | 2009-07-23 | 14 | 3d | 0d |  |
| 19 | 4.2 | T10: Shear stress/strain in non-birefringent materials |  | 20d | 2009-07-24 | 2009-08-20 | 18 | 116d | 0d |  |
| 20 | 4.3 | T11: Testing and evaluation |  | 40d | 2009-08-21 | 2009-10-15 | 19 | 116d |  |  |
| 21 | 5 | **Workpackage 4: Thermographic Systems** |  | 100d | 2009-07-24 | 2009-12-10 |  | 3d |  |  |
| 22 | 5.1 | T12: Continuous measurements using FLIR |  | 20d | 2009-07-24 | 2009-08-20 | 18 | 3d | 0d |  |
| 23 | 5.2 | T13: Thermoelastic stress measurents using FLIR |  | 20d | 2009-08-21 | 2009-09-17 | 22 | 76d | 0d |  |
| 24 | 5.3 | T14: Transient measurements using TWIPTS |  | 20d | 2009-09-18 | 2009-10-15 | 23 | 76d | 0d |  |
| 25 | 5.4 | T15: Testing and evaluation |  | 40d | 2009-10-16 | 2009-12-10 | 24 | 76d |  |  |
| 26 | 5.5 | Steering group meeting | milestone | 1d | 2009-10-16 | 2009-10-16 | 24 | 115d |  |  |

| ID | WBS | Task | Type | Duration | Start | Finish | Predecessors | Total slack | Free slack | Constraint |
| --- | --- | --- | --- | --- | --- | --- | --- | --- | --- | --- |
| 27 | 6 | **Workpackage 5: Ultrasonic B-Scan** |  | 136d | 2009-08-21 | 2010-02-26 |  | 3d |  |  |
| 28 | 6.1 | T16: Time-domain measurements |  | 20d | 2009-08-21 | 2009-09-17 | 22 | 3d | 0d |  |
| 29 | 6.2 | T17: Advanced digital signal processing |  | 20d | 2009-09-18 | 2009-10-15 | 28 | 3d | 0d |  |
| 30 | 6.3 | T18: Phased array measurements |  | 20d | 2009-10-16 | 2009-11-12 | 29 | 3d | 0d |  |
| 31 | 6.4 | T19: Testing and evaluation (whole system testing) |  | 76d | 2009-11-13 | 2010-02-26 | 30 | 3d | 0d |  |
| 32 | 7 | **Workpackage 6: Management, Reporting and Dissemination** |  | 239d | 2009-05-01 | 2010-03-31 |  | 0d |  |  |
| 33 | 7.1 | T20: Project management |  | 239d | 2009-05-01 | 2010-03-31 |  | 0d |  |  |
| 34 | 7.2 | **T21: Project evaluation** |  | 140d | 2009-07-06 | 2010-01-15 |  | 53d |  |  |
| 35 | 7.2.1 | Project evaluation 1 |  | 10d | 2009-07-06 | 2009-07-17 |  | 183d |  | start no earlier than 2009-07-06 |
| 36 | 7.2.2 | Project evaluation 2 |  | 10d | 2009-10-05 | 2009-10-16 |  | 118d |  | start no earlier than 2009-10-05 |
| 37 | 7.2.3 | Project evaluation 3 |  | 10d | 2010-01-04 | 2010-01-15 |  | 53d |  | start no earlier than 2010-01-04 |
| 38 | 7.3 | **T22: Project reporting** |  | 135d | 2009-07-20 | 2010-01-22 |  | 48d |  |  |
| 39 | 7.3.1 | 1 |  | 5d | 2009-07-20 | 2009-07-24 |  | 178d |  | start no earlier than 2009-07-20 |
| 40 | 7.3.2 | 2 |  | 5d | 2009-10-19 | 2009-10-23 |  | 113d |  | start no earlier than 2009-10-19 |
| 41 | 7.3.3 | 3 |  | 5d | 2010-01-18 | 2010-01-22 |  | 47d | 0d | start no earlier than 2010-01-18 |
| 42 | 7.4 | T23: Project final report preparation |  | 20d | 2010-03-01 | 2010-03-26 | 31 | 3d |  |  |
| 43 | 7.5 | Steering group meeting | milestone | 1d | 2010-01-25 | 2010-01-25 | 41 | 47d |  |  |
| 44 | 7.6 | Final dissemination event | milestone | 1d | 2010-03-26 | 2010-03-26 |  | 3d |  | start no earlier than 2010-03-26 |
